Schedule from Planner, 2014-10-01 to 2016-09-12.

## Calendars

- Default: Mon-Fri 08:00-12:00, 13:00-17:00; Sat-Sun off.

## Schedule

| ID | Task | Type | Duration | Start | Finish | Predecessors | Constraint | Work |
| --- | --- | --- | --- | --- | --- | --- | --- | --- |
| 1 | Preparation for Servicing Mission 3 |  |  | 2014-10-01 | 2014-11-25 |  |  | 320h |
| 2 | Data Release 3 | milestone | 0d | 2014-11-25 | 2014-11-25 | 1 |  |  |
| 3 | Antarctic Deployment |  |  | 2014-11-26 | 2015-01-20 | 1 |  | 320h |
| 4 | Commissioning 809 & 1460 GHz observations |  |  | 2015-01-21 | 2015-03-03 | 3 |  | 240h |
| 5 | Galactic Plane and LMC Surveys in [CI] and [NII] |  |  | 2015-03-04 | 2015-12-08 | 4 |  | 1600h |
| 6 | Data Release 4 | milestone | 0d | 2015-03-20 | 2015-03-20 |  | must start on 2015-03-20 |  |
| 7 | Analysis and Publication |  |  | 2015-03-04 | 2015-12-08 | 4 |  | 1600h |
| 8 | Preparation for Servicing Mission 4 |  |  | 2015-11-02 | 2015-12-11 |  | must start on 2015-11-01 | 240h |
| 9 | Data Release 5 | milestone | 0d | 2015-11-25 | 2015-11-25 |  | must start on 2015-11-25 |  |
| 10 | Antarctic Deployment |  |  | 2015-12-14 | 2016-01-29 | 8 |  | 280h |
| 11 | Analysis and Publication |  |  | 2016-02-01 | 2016-09-12 | 10 |  | 1283h |
| 12 | Data Release 6 | milestone | 0d | 2016-03-21 | 2016-03-20 |  | must start on 2016-03-20 |  |
